# ALCANTARILLADO SAN FRANCISCO DE SALES

Schedule from MS Project, 2015-06-01 to 2015-11-28, costs in $.
HP

## Calendars

- Estándar: Mon-Sun 09:00-13:00, 15:00-19:00.

## Schedule

| ID | WBS | Task | Type | Duration | Start | Finish | Predecessors | Total slack | Free slack | Cost |
| --- | --- | --- | --- | --- | --- | --- | --- | --- | --- | --- |
| 1 | 1 | Inicio Proyecto | milestone | 0d | 2015-06-01 | 2015-06-01 |  | 0d |  |  |
| 2 | 2 | **ALCANTARILLADO SANITARIO CORTO PLAZO** |  | 126d | 2015-06-01 | 2015-10-05 |  | 54d |  | 677,284,074.25 |
| 3 | 2.1 | COMPRA Y ACOPIO DE SUMINISTROS |  | 2d | 2015-06-01 | 2015-06-03 | 1 | 178d |  | 173,614,715.46 |
| 4 | 2.2 | LOCALIZACIÓN, REPLANTEO Y SEÑALIZACIÓN DE REDES |  | 60d | 2015-06-01 | 2015-07-31 | 1 | 54d | 0d | 27,044,156.61 |
| 5 | 2.3 | DEMOLICIONES |  | 23d | 2015-06-26 | 2015-07-19 | 4FS-35d | 132d |  | 13,147,590.83 |
| 6 | 2.4 | EXCAVACIÓN DE ZANJA PARA TUBERÍAS Y POZOS |  | 90d | 2015-06-06 | 2015-09-04 | 4FS-55d | 54d | 0d | 37,953,599.45 |
| 7 | 2.5 | ENTIBADOS |  | 45d | 2015-07-16 | 2015-08-30 | 6FS-50d | 90d |  | 29,515,307.14 |
| 8 | 2.6 | RELLENOS Y RETIRO DE MATERIAL |  | 80d | 2015-07-16 | 2015-10-04 | 6FS-50d | 55d |  | 152,269,531.81 |
| 9 | 2.7 | INSTALACIÓN DE TUBERÍA EN PVC PARA ALCANTARILLADOS |  | 51d | 2015-07-16 | 2015-09-05 | 6FS-50d | 54d | 0d | 15,450,398.83 |
| 10 | 2.8 | CONSTRUCCIÓN DE POZOS Y CAJAS DE INSPECCIÓN |  | 60d | 2015-08-05 | 2015-10-04 | 6FS-30d | 55d | 0d | 163,316,760.43 |
| 11 | 2.9 | CONCRETOS MORTEROS ACERO DE REFUERZO Y ADITIVOS |  | 13d | 2015-09-21 | 2015-10-04 | 10FS-13d | 55d |  | 5,284,366.2 |
| 12 | 2.10 | CONEXIONES DOMICILIARIAS |  | 45d | 2015-08-15 | 2015-09-29 | 6FS-20d | 60d |  | 19,927,978.12 |
| 13 | 2.11 | RECONSTRUCCION DE PAVIMENTOS, ANDENES Y SARDINELES |  | 33d | 2015-09-02 | 2015-10-05 | 9FS-3d | 54d |  | 39,759,669.37 |
| 14 | 3 | **ALCANTARILLADO PLUVIAL** |  | 128d | 2015-07-21 | 2015-11-26 |  | 2d |  | 1,458,900,136.12 |
| 15 | 3.1 | COMPRA Y ACOPIO DE SUMINISTROS |  | 2d | 2015-07-21 | 2015-07-23 | 1FS+50d | 128d |  | 325,573,394.44 |
| 16 | 3.2 | LOCALIZACIÓN, REPLANTEO Y SEÑALIZACIÓN DE REDES |  | 100d | 2015-07-21 | 2015-10-29 | 1FS+50d | 2d | 0d | 19,709,507.67 |
| 17 | 3.3 | DEMOLICIONES |  | 60d | 2015-08-30 | 2015-10-29 | 16FS-60d | 30d |  | 43,568,221.38 |
| 18 | 3.4 | EXCAVACIÓN DE ZANJA PARA TUBERÍAS Y POZOS |  | 100d | 2015-08-10 | 2015-11-18 | 16FS-80d | 2d | 0d | 76,357,834.05 |
| 19 | 3.5 | ENTIBADOS |  | 90d | 2015-08-25 | 2015-11-23 | 18FS-85d | 5d | 0d | 67,638,711.53 |
| 20 | 3.6 | RELLENOS Y RETIRO DE MATERIAL |  | 95d | 2015-08-20 | 2015-11-23 | 18FS-90d | 5d |  | 333,383,019.28 |
| 21 | 3.7 | INSTALACIÓN DE TUBERÍA EN PVC PARA ALCANTARILLADOS |  | 83d | 2015-08-30 | 2015-11-21 | 18FS-80d | 2d | 0d | 28,011,408.04 |
| 22 | 3.8 | CONSTRUCCIÓN DE POZOS Y CÁMARAS DE CAÍDA |  | 80d | 2015-08-15 | 2015-11-03 | 18FS-95d | 25d | 0d | 251,002,180.13 |
| 23 | 3.9 | CONCRETOS MORTEROS ACERO DE REFUERZO Y ADITIVOS |  | 33d | 2015-10-01 | 2015-11-03 | 22FS-33d | 25d |  | 16,089,561.06 |
| 24 | 3.10 | SUMIDEROS |  | 33d | 2015-10-16 | 2015-11-18 | 19FS-38d | 10d |  | 177,615,740.03 |
| 25 | 3.11 | RECONSTRUCCION DE PAVIMENTOS, ANDENES Y SARDINELES |  | 20d | 2015-11-06 | 2015-11-26 | 21FS-15d | 2d |  | 119,950,558.51 |
| 26 | 4 | AMBIENTAL |  | 180d | 2015-06-01 | 2015-11-28 | 1 | 0d |  | 4,610,364 |
| 27 | 5 | FIN DEL PROYECTO | milestone | 0d | 2015-11-28 | 2015-11-28 | 26 | 0d |  |  |
